Schedule from Primavera P6.

## Schedule

| ID | Activity | Duration | Predecessors | Complete |
| --- | --- | --- | --- | --- |
| A100 | Mobilise | 10d |  | 100% |
| A110 | Excavate | 25d | A100 | 100% |
| A120 | Piling | 30d | A110 | 100% |
| A130 | Foundations | 20d | A120 | 100% |
| A140 | Steelwork erection | 40d | A130 | 100% |
| A150 | Cladding | 20d | A140 SS+5d | 100% |
| A160 | M&E installation | 25d | A140 | 100% |
| A170 | Commissioning | 15d | A160, A150 | 100% |
| A190 | Snagging | 7.5d | A170 | 100% |
